# Cronograma

Schedule from MS Project, 2016-02-03 to 2016-12-23, costs in $, A marks actual dates.

## Calendars

- Calendario NewConcept: Mon-Fri 09:00-13:00, 15:00-19:00; Sat-Sun off.

## Schedule

| ID | WBS | Task | Duration | Start | Finish | Predecessors | Complete | Remaining | Total slack | Constraint | Cost | Actual cost |
| --- | --- | --- | --- | --- | --- | --- | --- | --- | --- | --- | --- | --- |
| 1 | 1 | **Constitución y Legalización Sociedad** | 46d | 2016-02-03 A | 2016-04-06 |  | 87% | 5.96d | 187d |  | 276,440 | 240,502.8 |
| 2 | 1.1 | **Búsqueda de Nombre para la Empresa** | 14d | 2016-02-03 A | 2016-02-22 A |  | 100% |  |  |  |  |  |
| 3 | 1.1.1 | Reunión por los socios accionistas para realizar una lluvia de ideas y así poder crear el nombre adecuado para la misma. | 5d | 2016-02-03 A | 2016-02-09 A |  | 100% |  |  | start no earlier than 2016-02-03 |  |  |
| 4 | 1.1.2 | Rectificación del nombre en la página de la CCB por humanidad para poder constituir la sociedad sin inconvenientes. | 2d | 2016-02-10 A | 2016-02-11 A | 3 | 100% |  |  |  |  |  |
| 5 | 1.1.3 | Solicitud de asesoría por los enrutadores y chat de la CCB para creación de Sociedad por acciones Simplificada, con guías en bibliotecas virtuales y formularios de constitución. | 7d | 2016-02-12 A | 2016-02-22 A | 4 | 100% |  |  |  |  |  |
| 6 | 1.2 | **Desarrollo Acta de constitución** | 10d | 2016-02-12 A | 2016-02-25 A |  | 100% |  |  |  |  |  |
| 7 | 1.2.1 | Reunión con los socios accionistas para generar el documento de constitución. tomando decisiones como: Estatutos, dinero en inversión inicial, costo y cantidad de acciones iniciales. | 10d | 2016-02-12 A | 2016-02-25 A | 4 | 100% |  |  |  |  |  |
| 8 | 1.3 | **Constitución de la sociedad (CCB)** | 16d | 2016-02-26 A | 2016-03-18 A |  | 100% |  |  |  |  |  |
| 9 | 1.3.1 | Realizar trámites frente a la CCB realizando citaciones para guía y seguimiento de la constitución de la sociedad por los abogados asignados. | 8d | 2016-02-26 A | 2016-03-08 A | 7 | 100% |  |  |  |  |  |
| 10 | 1.3.2 | Generación de formulario para creación de cuenta bancaria de la sociedad. | 8d | 2016-03-09 A | 2016-03-18 A | 9 | 100% |  |  |  |  |  |
| 11 | 1.4 | **Generación de RUT (DIAN)** | 5d | 2016-03-21 A | 2016-03-25 A |  | 100% |  |  |  |  |  |
| 12 | 1.4.1 | Solicitar cita con asesor de DIAN. | 3d | 2016-03-21 A | 2016-03-23 A | 10 | 100% |  |  |  |  |  |
| 13 | 1.4.2 | Generación del RUT real de la empresa para, y sustituir el Pre-RUT utilizado para trámites en CCB y creación de cuenta bancaria. | 1d | 2016-03-24 A | 2016-03-24 A | 12 | 100% |  |  |  |  |  |
| 14 | 1.4.3 | Solicitud de firmas virtuales para trámites frente a la DIAN. | 1d | 2016-03-25 A | 2016-03-25 A | 13 | 100% |  |  |  |  |  |
| 15 | 1.5 | **Inscripción libro de actas y accionistas** | 2d | 2016-03-25 A | 2016-03-28 A |  | 100% |  |  |  |  |  |
| 16 | 1.5.1 | Numeración de libros de actas y accionistas, para inscripción de los mimos bajo la guía de asesores de CCB. | 1d | 2016-03-25 A | 2016-03-25 A | 13 | 100% |  |  |  |  |  |
| 17 | 1.5.2 | Consignación y pago de inscripciones libros. | 1d | 2016-03-28 A | 2016-03-28 A | 16 | 100% |  |  |  |  |  |
| 18 | 1.6 | Solicitud de Facturación (DIAN) | 7d | 2016-03-29 | 2016-04-06 | 15 |  |  | 187d |  |  |  |
| 19 | 2 | **Desarrollo Prototipo** | 38d | 2016-03-29 A | 2016-05-19 A |  | 100% |  |  |  | 250,000 | 250,000 |
| 20 | 2.1 | Reunión de socios para lluvia de ideas sobre ruta para inicio de prototipo | 2d | 2016-03-29 A | 2016-03-30 A | 17 | 100% |  |  |  |  |  |
| 21 | 2.2 | Toma de decisiones sobre prioridad, costo inicial, desarrollo, publicidad, métodos de mercadeo de las ideas generadas en una reunión previa. | 3d | 2016-03-31 A | 2016-04-04 A | 20 | 100% |  |  |  |  |  |
| 22 | 2.3 | **Puesta a Punto** | 33d | 2016-04-05 A | 2016-05-19 A | 21 | 100% |  |  |  |  |  |
| 23 | 2.3.1 | Montaje de prototipo de seguridad en puerta eléctrica durante 1 mes, esperando satisfacer las necesidades del cliente en todos los sentidos como: seguridad, calidad y confiabilidad del producto. | 30d | 2016-04-05 A | 2016-05-16 A |  | 100% |  |  |  |  |  |
| 24 | 2.3.2 | Corrección de fallas generadas en periodo de prueba | 3d | 2016-05-17 A | 2016-05-19 A | 23 | 100% |  |  |  |  |  |

| ID | WBS | Task | Duration | Start | Finish | Predecessors | Complete | Remaining | Total slack | Constraint | Cost | Actual cost |
| --- | --- | --- | --- | --- | --- | --- | --- | --- | --- | --- | --- | --- |
| 25 | 3 | **Inicio Actividad Económica** | 156d | 2016-05-20 A | 2016-12-23 | 24 | 21% | 122.57d | 0d |  | 100,000 | 21,000 |
| 26 | 3.1 | **Busqueda de Clientes** | 156d | 2016-05-20 A | 2016-12-23 |  | 21% | 122.57d | 0d |  |  |  |
| 27 | 3.1.1 | Busqueda de Clientes 1 | 10d | 2016-05-20 A | 2016-06-02 A |  | 100% |  |  | start no earlier than 2016-05-20 |  |  |
| 28 | 3.1.2 | Busqueda de Clientes 2 | 10d | 2016-06-29 A | 2016-07-12 |  | 50% | 5d | 118d | start no earlier than 2016-06-29 |  |  |
| 29 | 3.1.3 | Busqueda de Clientes 3 | 10d | 2016-08-08 | 2016-08-19 |  |  |  | 90d | start no earlier than 2016-08-08 |  |  |
| 30 | 3.1.4 | Busqueda de Clientes 4 | 10d | 2016-09-12 | 2016-09-23 |  |  |  | 65d | start no earlier than 2016-09-12 |  |  |
| 31 | 3.1.5 | Busqueda de Clientes 5 | 10d | 2016-10-10 | 2016-10-21 |  |  |  | 45d | start no earlier than 2016-10-10 |  |  |
| 32 | 3.1.6 | Busqueda de Clientes 6 | 10d | 2016-11-14 | 2016-11-25 |  |  |  | 20d | start no earlier than 2016-11-14 |  |  |
| 33 | 3.1.7 | Busqueda de Clientes 7 | 10d | 2016-12-12 | 2016-12-23 |  |  |  | 0d | start no earlier than 2016-12-12 |  |  |
| 34 | 4 | **Desarrollo página Web** | 35d | 2016-03-28 A | 2016-05-13 |  | 90% | 3.5d | 160d |  | 53,698 | 48,328.2 |
| 35 | 4.1 | Adquisición del Dominio | 2d | 2016-03-28 A | 2016-03-29 A |  | 100% |  |  | start no earlier than 2016-03-28 |  |  |
| 36 | 4.2 | Selección del proveedor de servicio de hospedaje | 10d | 2016-03-30 A | 2016-04-12 A | 35 | 100% |  |  | start no earlier than 2016-03-30 |  |  |
| 37 | 4.3 | Pago del Servicio de hospedaje | 1d | 2016-04-13 A | 2016-04-13 A | 36 | 100% |  |  |  |  |  |
| 38 | 4.4 | Selección de la aplicación para desarrollo de la página Web | 10d | 2016-04-14 A | 2016-04-27 A | 37 | 100% |  |  |  |  |  |
| 39 | 4.5 | Implementación de la Aplicación en el Hospedaje | 10d | 2016-04-28 A | 2016-05-11 | 38 | 50% | 5d | 162d |  |  |  |
| 40 | 4.6 | Enlace del Dominio con la aplicación | 2d | 2016-05-12 A | 2016-05-13 A | 39 | 100% |  |  |  |  |  |
| 41 | 4.7 | Selección del proveedor de servicios de correo | 10d | 2016-04-13 A | 2016-04-26 A | 36 | 100% |  |  |  |  |  |
| 42 | 4.8 | Configuración de Servicios de correo | 5d | 2016-04-27 A | 2016-05-03 A | 41 | 100% |  |  |  |  |  |
